# Plan Anual Indisponibilidades Programadas 2013

Schedule from MS Project, 2021-01-13 to 2021-12-12, 24 hours a day.

## Calendars

- 24 horas: Mon-Sun 00:00-24:00.

## Schedule

| ID | Task | Type | Duration | Start | Finish | Text3 | solicitud | SOLMANT | Observaciones |
| --- | --- | --- | --- | --- | --- | --- | --- | --- | --- |
| 1 | LT230kV Pirrís Parrita | manual | 0.25d | 2021-01-13 07:00 | 2021-01-13 13:00 | RCH | 41600 |  |  |
| 2 | LT230kV Trapiche Leesville | manual | 0.42d | 2021-05-19 07:00 | 2021-05-19 17:00 | RHT |  | 14 |  |
| 3 | LT230kV Palmar Río Claro #2 | manual | 2.46d | 2021-02-08 07:00 | 2021-02-10 18:00 | EPR |  |  |  |
| 4 | Subestación Moín Enlace de barras 138 kV | manual | 0.42d | 2021-02-11 07:00 | 2021-02-11 17:00 | RHT |  | No RTR |  |
| 5 | LT138kV Escazú Desamparados | manual | 0.42d | 2021-05-20 07:00 | 2021-05-20 17:00 | RCN |  | no RTR |  |
| 6 | LT230kV Palmar Parrita | manual | 2.46d | 2021-05-24 07:00 | 2021-05-26 18:00 | EPR |  | 15 |  |
| 7 | LT230kV Venecia Toro | manual | 0.42d | 2021-07-04 07:00 | 2021-07-04 17:00 | RCN |  | 24 |  |
| 8 | Subestación Río Macho barra B 138 kV | manual | 0.42d | 2021-10-19 07:00 | 2021-10-19 17:00 | RHT |  | 42 |  |
| 9 | LT138kV Escazu La Caja | manual | 0.42d | 2021-06-29 07:00 | 2021-06-29 17:00 | RCN |  | 22 |  |
| 10 | Subestación La Caja Autotransformador #3 | manual | 4.42d | 2021-03-01 07:00 | 2021-03-05 17:00 | RCN |  |  |  |
| 11 | LT138kV Río Macho Desamparados | manual | 1.42d | 2021-06-24 07:00 | 2021-06-25 17:00 | RHT |  | no RTR |  |
| 12 | Subestación Garita Barra 230 kV y Subestacion Balsa barra A 230 kV | manual | 0.42d | 2021-05-30 07:00 | 2021-05-30 17:00 | RCN |  |  |  |
| 13 | LT230kV Parrita Jaco | manual | 2.46d | 2021-06-08 07:00 | 2021-06-10 18:00 | EPR |  | 17 |  |
| 14 | ST Leesville barra principal 230 kV y LT230kV Leesville General | manual | 10h | 2021-02-11 07:00 | 2021-02-11 17:00 | RHT | 40362 | 53 | Requiere inclusión |
| 15 | LT230kV Rio Claro Dominical | manual | 3.54d | 2021-02-01 06:00 | 2021-02-04 19:00 | EPR | 41598 |  | Requiere inclusión |
| 16 | Subestación Río Claro barra B 230 kV LT230kV Río Claro Palmar #2. | manual | 12h | 2021-02-02 07:00 | 2021-02-02 19:00 | RHT | 40939 |  | Requiere inclusión |
| 17 | Subestación Río Claro barra A 230 kV | manual | 0.42d | 2021-01-27 07:00 | 2021-01-27 17:00 | RHT |  |  |  |
| 18 | LT230kV Palmar San Isidro | manual | 0.42d | 2021-03-25 07:00 | 2021-03-25 17:00 | RHT |  |  |  |
| 19 | LT138kV Angostura Turrialba | manual | 0.42d | 2021-04-06 07:00 | 2021-04-06 17:00 | RHT |  |  |  |
| 20 | LT138kV Concavas Alajuelita | manual | 0.42d | 2021-07-01 07:00 | 2021-07-01 17:00 | RHT |  | no RTR |  |
| 21 | LT138kV La Caja Garita | manual | 0.42d | 2021-05-07 07:00 | 2021-05-07 17:00 | RCN |  | 11 |  |
| 22 | Subestación Palmar Barra B 230 kV | manual | 0.42d | 2021-05-26 07:00 | 2021-05-26 17:00 | RHT |  |  |  |
| 23 | Subestación Barranca Barra 138 kV | manual | 0.42d | 2021-04-20 07:00 | 2021-04-20 17:00 | RCH |  | no RTR |  |
| 24 | Subestación Barranca Barra 230 kV | manual | 0.42d | 2021-06-23 07:00 | 2021-06-23 17:00 | RCH |  | 21 |  |
| 25 | LT230kV Tejar Río Macho | manual | 0.42d | 2021-04-21 07:00 | 2021-04-21 17:00 | RHT |  |  |  |
| 26 | LT230kV Torito Río Macho | manual | 0.42d | 2021-07-02 07:00 | 2021-07-02 17:00 | RHT |  | 23 |  |
| 27 | Subestación Lindora Enlace de barras 230 kV | manual | 0.42d | 2021-05-06 07:00 | 2021-05-06 17:00 | RCN |  | 10 |  |
| 28 | LT230kV Moín Trapiche | manual | 0.42d | 2021-05-11 07:00 | 2021-05-11 17:00 | RHT |  | 12 |  |
| 29 | LT230kV Garabito Coyol | manual | 0.42d | 2021-07-16 07:00 | 2021-07-16 17:00 | RCN |  | no RTR |  |
| 30 | LT138kV Santa Rita Colorado | manual | 0.25d | 2021-05-12 07:00 | 2021-05-12 13:00 | RCH |  | no RTR |  |
| 31 | Subestación Coco Barra 138 kV | manual | 0.42d | 2021-05-16 07:00 | 2021-05-16 17:00 | RCN |  | 13 |  |
| 32 | Subestación La Caja Autotransformador #3 | manual | 13.42d | 2021-05-31 07:00 | 2021-06-13 17:00 | RCN |  | 16 |  |
| 33 | LT138kV Río Macho Concavas | manual | 0.42d | 2021-06-22 07:00 | 2021-06-22 17:00 | RHT |  | 20 |  |
| 34 | Subestación Miravalles Barra A 230 kV | manual | 0.33d | 2021-12-12 07:00 | 2021-12-12 15:00 | RCH |  | 51 |  |
| 35 | LT138kV Poas Garita | manual | 0.42d | 2021-06-09 07:00 | 2021-06-09 17:00 | RCN |  | no RTR |  |
| 36 | Subestación Río Macho Autotransformador #1 | manual | 4.25d | 2021-06-14 08:00 | 2021-06-18 14:00 | RHT |  | 18 |  |
| 37 | LT230kV Cañas Jacó | manual | 1.42d | 2021-06-15 07:00 | 2021-06-16 17:00 | EPR |  | 19 |  |
| 38 | LT230kV Arenal Lindora | manual | 0.42d | 2021-06-17 07:00 | 2021-06-17 17:00 | RCN |  | no RTR |  |
| 39 | LT230kV Garabito Coyol | manual | 0.33d | 2021-06-18 07:00 | 2021-06-18 15:00 | RCH |  | no RTR |  |
| 40 | Subestación Miravalles Barra B 230kV | manual | 0.42d | 2021-12-05 07:00 | 2021-12-05 17:00 | RCH |  | 47 |  |
| 41 | LT138kV San Miguel Colima #2 y LT138kV Cachí San Miguel | manual | 0.42d | 2021-06-27 07:00 | 2021-06-27 17:00 | RCN |  | no RTR |  |
| 42 | Subestación Tarbaca Barra A y Barra B 230kV | manual | 6.35d | 2021-07-12 08:30 | 2021-07-18 17:00 | RCN |  | 25 |  |
| 43 | LT138kV Cachí Turrialba | manual | 0.42d | 2021-07-13 07:00 | 2021-07-13 17:00 | RHT |  | 26 |  |
| 44 | LT230kV Tejona Arenal | manual | 0.21d | 2021-07-18 07:00 | 2021-07-18 12:00 | RCH |  | 27 |  |
| 45 | LT230kV Río Claro Palmar #1 | manual | 0.42d | 2021-07-15 07:00 | 2021-07-15 17:00 | RHT |  | no RTR |  |
| 46 | LT230kV Pailas Mogote | manual | 0.25d | 2021-08-22 07:00 | 2021-08-22 13:00 | RCH |  | 33 |  |
| 47 | LT230kV Garabito Cañas | manual | 0.33d | 2021-07-25 07:00 | 2021-07-25 15:00 | RCH |  | 28 |  |
| 48 | Subestación Tarbaca Barra A y Barra B 230kV | manual | 0.42d | 2021-08-01 07:00 | 2021-08-01 17:00 | RCN |  | 29 |  |
| 49 | Subestación La Caja Autotransformador #1 | manual | 6.42d | 2021-08-03 07:00 | 2021-08-09 17:00 | RCN |  | 30 |  |
| 50 | LT230kV Tarbaca Parrita | manual | 0.42d | 2021-08-13 07:00 | 2021-08-13 17:00 | RCN |  | 32 |  |
| 51 | LT138kV Naranjo Garita | manual | 0.42d | 2021-08-11 07:00 | 2021-08-11 17:00 | RCN |  | no RTR |  |
| 52 | LT230kV Miravalles Arenal | manual | 0.38d | 2021-12-05 07:00 | 2021-12-05 16:00 | RCH |  | 48 |  |
| 53 | Subestación Moín Enlace de barras 230kV | manual | 0.42d | 2021-08-12 07:00 | 2021-08-12 17:00 | RHT |  | 31 |  |
| 54 | LT230kV Mogote Miravalles | manual | 0.25d | 2021-12-12 07:00 | 2021-12-12 13:00 | RCH |  | 52 |  |
| 55 | Subestación Coronado Enlace de barras 230kV | manual | 0.42d | 2021-08-27 07:00 | 2021-08-27 17:00 | RCN |  | 34 |  |
| 56 | LT138kV Cachí Angostura | manual | 0.42d | 2021-09-07 07:00 | 2021-09-07 17:00 | RHT |  | 35 |  |
| 57 | LT230kV La Caja Coyol | manual | 4.42d | 2021-09-13 07:00 | 2021-09-17 17:00 | RCN |  | no RTR |  |
| 58 | LT138kV Sabanilla Cachí | manual | 0.42d | 2021-09-21 07:00 | 2021-09-21 17:00 | RCN |  | no RTR |  |
| 59 | Subestación Arenal Barra A 230kV | manual | 0.42d | 2021-10-10 07:00 | 2021-10-10 17:00 | RCH |  | 39 |  |
| 60 | LT230kV Mogote Pailas | manual | 0.25d | 2021-10-03 07:00 | 2021-10-03 13:00 | RCH |  | 38 |  |
| 61 | Subestación Heredia Barra 138kV | manual | 0.33d | 2021-09-26 07:00 | 2021-09-26 15:00 | RCN |  | no RTR |  |
| 62 | Subestación Garita Autotransformador #1 | manual | 4.42d | 2021-10-04 07:00 | 2021-10-08 17:00 | RCN |  | no RTR |  |
| 63 | LT230kV La Caja Lindora #2 | manual | 4.42d | 2021-10-11 07:00 | 2021-10-15 17:00 | RCN |  | 40 |  |
| 64 | Subestación Cachí Barra A 138kV | manual | 0.42d | 2021-09-24 07:00 | 2021-09-24 17:00 | RHT |  | 36 |  |
| 65 | Subestación Cachí Barra B 138kV | manual | 0.42d | 2021-09-25 07:00 | 2021-09-25 17:00 | RHT |  | 37 |  |
| 66 | Subestación Peñas Blancas Barra 230 kV | manual | 0.42d | 2021-10-17 07:00 | 2021-10-17 17:00 | RCH |  | 41 | Verificar si es únicamente LT230kV TEJ PBL |
| 67 | Subestación Angostura Barra A 138kV | manual | 0.42d | 2021-10-22 07:00 | 2021-10-22 17:00 | RHT |  | 43 |  |
| 68 | Subestación Angostura Barra B 138kV | manual | 0.42d | 2021-10-25 07:00 | 2021-10-25 17:00 | RHT |  | 45 |  |
| 69 | LT230kV General Cariblanco | manual | 0.42d | 2021-11-16 07:00 | 2021-11-16 17:00 | RHT |  | 46 |  |
| 70 | Subestación San Miguel Barra B 230kV | manual | 0.42d | 2021-10-24 07:00 | 2021-10-24 17:00 | RCN |  | 44 |  |

Notes:
- 1: Text4: Pruebas a transformadores de instrumento y pruebas de calidad de gas SF6 en el interruptor
- 2: Text4: Mantenimiento, ajuste lubricación y pruebas a seccionadoras de línea, puesta a tierra y derivación. Mantenimiento general y pruebas electricas a transformadores de instrumentos, y pararrayos. Revisión funcional de los Interruptores de potencia en ambos mó
- 3: Text4: Se realizara mantenimiento completo y pruebas eléctricas a equipo primario. Cambio de aisladores, colocación de abrazaderas en grapas fisuradas. Reparación en OPGW.
- 4: Text4: Revisión funcional del Interruptor de potencia
- 5: Text4: Revisión funcional del Interruptor de potencia
- 6: Text4: Se realizara mantenimiento completo y pruebas eléctricas a equipo primario. En Parrita se realizara mantenimiento a las seccionadoras que conectan el bajante de línea, colocación de abrazaderas en grapas fisuradas. Reparación en OPGW.
- 7: Text4: Sustitución de aisladores dañados
- 8: Text4: Mantenimiento general a elementos de barra principal mantenimiento de seccionadoras y pruebas eléctricas a transformadores de potencial.
- 9: Text4: Revisión funcional del Interruptor de potencia
- 10: Text4: Cambio de equipos nuevos.
- 11: Text4: Sustitución de aisladores por deterioro
- 12: Text4: Prueba funcional al relé diferencial de barras 230kV en SUBESTACIÓN Garita. Cambio de aisladores dañados en la LT Balsa-Garita. Revisión funcional del Interruptor del Enlace de Barras 230kV en SUBESTACIÓN Balsa. Revisión funcional al Interruptor del Módul
- 13: Text4: Se realizara mantenimiento completo y pruebas eléctricas a equipo primario. Cambio de aisladores, colocación de abrazaderas en grapas fisuradas. Reparación en OPGW.
- 14: Text4: Para realizar mantenimiento correctivo a las seccionadoras de barra de los módulos
- 15: Text4: Sustitución de rele SEL 311L por 411L
- 16: Text4: Mantenimiento a las seccionadoras de barra
- 17: Text4: Mantenimiento de seccionadoras de barra principal y pruebas eléctricas a transformadores de potencial.
- 18: Text4: Mantenimiento, ajuste lubricación y pruebas a seccionadoras de línea, puesta a tierra y derivación. Mantenimiento general a transformadores de instrumentos, y pararrayos. Pruebas eléctricas a transformadores de instrumento y pararrayos. Revisión funcional
- 19: Text4: Mantenimiento, ajuste lubricación y pruebas a seccionadoras de línea, puesta a tierra y derivación. Mantenimiento general y pruebas electricas a Transformadores de instrumentos, y pararrayos. Revisión funcional de los Interruptores de potencia en ambos mó
- 20: Text4: Reemplazo de aisladores por deterioro, ajuste lubricación y pruebas a seccionadoras de línea, puesta a tierra y derivación. Mantenimiento general a transformadores de instrumentos, y pararrayos. Pruebas eléctricas a transformadores de instrumento y pararr
- 21: Text4: Cambio de amortiguadores dañados
- 22: Text4: Mantenimiento general a seccionadoras de barra. Mantenimiento y pruebas electricas a transformadores de potencial.
- 23: Text4: Sustituciòn potenciales de barra. Desconexiòn seccionadora barra Unidad 1. Desconexiòn seccionadora Barra Unidad 2 Pruebas gas SF6 a Interruptores asociados a la barra
- 24: Text4: Pruebas electricas a transformadores de potencial, pruebas gas SF6 a Interruptores asociados a la barra. Mantenimiento general a seccionadoras asociadas a la barra
- 25: Text4: Mantenimiento, ajuste lubricación y pruebas a seccionadoras de línea, puesta a tierra y derivación. Mantenimiento general a transformadores de instrumentos, y pararrayos. Pruebas eléctricas a transformadores de instrumento y pararrayos. Revisión funcional
- 26: Text4: Mantenimiento, ajuste lubricación y pruebas a seccionadoras de línea, puesta a tierra y derivación. Mantenimiento general a transformadores de instrumentos, y pararrayos. Pruebas eléctricas a transformadores de instrumento y pararrayos. Revisión funcional
- 27: Text4: Revisión funcional del Interruptor de potencia
- 28: Text4: Mantenimiento, ajuste lubricación y pruebas a seccionadoras de línea, puesta a tierra y derivación. Mantenimiento general a transformadores de instrumentos, y pararrayos. Pruebas eléctricas a transformadores de instrumento y pararrayos. Revisión funcional
- 29: Text4: Sustitución de hilo guarda 3/8 por nuevo, vano 82-83
- 30: Text4: Cambio y pruebas electricas a transformadores de potencial.
- 31: Text4: Prueba funcional rele diferencial de barra y canales de disparo. Prueba disparos transferidos y falla de interruptor. Cambio de amortiguadores dañados.
- 32: Text4: Pruebas electricas y puesta en marcha del autotransformador #3
- 33: Text4: Cierre de puentes (jumpers) con mangas de compresión
- 34: Text4: Cambio de conductores dañados en barra.
- 35: Text4: Retensado de varios vanos de dotterel para garantizar distancias eléctricas respecto a conductores
- 36: Text4: Revisión funcional. Limpieza de gabinetes, corrección oxidación, pruebas de protecciones propias y pruebas electricas al autotransformador.
- 37: Text4: Cambio de aisladores y/o accesorios. Colocación de abrazaderas en grapas fisuradas. Reparaciones en cable OPGW .
- 38: Text4: Instalación de extensiones en aisladores epóxicos para eliminar puntos calientes
- 39: Text4: Reparación de hilo guarda y revisión de pararrayos. Pruebas a los relés de protección del modulo, se intervendran esporadicamente datos.
- 40: Text4: Pruebas eléctricas a transformadores de potencial. Corrección de puntos calientes en seccionadora 289l-2 módulo Mogote.
- 41: Text4: Cambio de aisladores epóxicos en torre del entronque
- 42: Text4: Cambio reles diferenciales 87B P2 en Barras A y B. Compresión de jumper, cambio de amortiguadores y de aisladores dañados. Pruebas electricas al Interruptor de portencia y transforma
- 43: Text4: Mantenimiento, ajuste lubricación y pruebas a seccionadoras de línea, puesta a tierra y derivación. Mantenimiento general a transformadores de instrumentos, y pararrayos. Pruebas eléctricas a transformadores de instrumento y pararrayos. Revisión funcional
- 44: Text4: Reconstruccion de seccionadoras 389L-3 389L-5 Y 289M-2.
- 45: Text4: Mantenimiento, ajuste lubricación y pruebas a seccionadoras de línea, puesta a tierra y derivación. Mantenimiento general a transformadores de instrumentos, y pararrayos. Pruebas eléctricas a transformadores de instrumento y pararrayos. Revisión funcional
- 46: Text4: Reconstrucciòn de seccionadoras 289L-3 289L-5 Y 289M-2.
- 47: Text4: Reparación de jumpers torre 23, revisión de herrajes de la torre 39 a la torre 43, y revisión OPGW.
- 48: Text4: Instalación, ajuste y pruebas funcionales de reles diferenciales 87B P1 en barras A y B. Compresión de jumper, cambio de amortiguadores y de aisladores dañados.
- 49: Text4: Revisión funcional pruebas electricas y revisión funcional de protecciones
- 50: Text4: Instalación, ajuste y pruebas funcionales de relés diferenciales de linea 87L en ambos extremos.
- 51: Text4: Cambio de aisladores dañados.
- 52: Text4: Instalación de parrayos para mejora del blindaje de la línea.
- 53: Text4: Revisión funcional del interruptor de potencia.
- 54: Text4: Reconstrucción de seccionadoras y pruebas de aislamiento a transformadores de instrumento en extremo de Subestación Mogote.
- 55: Text4: Revisión funcional del interruptor de potencia.
- 56: Text4: Mantenimiento, ajuste lubricación y pruebas a seccionadoras de línea, puesta a tierra y derivación. Mantenimiento general a transformadores de instrumentos y pararrayos. Revisión funcional del interruptor de potencia.
- 57: Text4: Cambio de unidad de control.
- 58: Text4: Mantenimiento, ajuste lubricación y pruebas a seccionadoras de línea, puesta a tierra y derivación. Mantenimiento general a transformadores de instrumentos y pararrayos. Revisión funcional del interruptor de potencia.
- 59: Text4: Pruebas eléctricas a transformadores de potencial. Corrección de puntos calientes en las seccionadoras de barra. Pruebas de calidad de gas SF6 a todos los Interruptores. Cambio de conectores de la seccionadora del enlace lado Barra A
- 60: Text4: Reconstrucción de seccionadoras en extremo de subestación Mogpte. Pruebas de aislamiento a transformadores de instrumento.
- 61: Text4: Prueba de canales de disparo y funcionales a relés diferenciales de barras 87B P1 y P2. Prueba disparos transferidos y falla de interruptor.
- 62: Text4: Revisión funcional del Autotransformador #1
- 63: Text4: Cambio de unidad de control.
- 64: Text4: Mantenimiento general a seccionadoras de barra principal, lavado, lubricación, ajustes y pruebas de resisitencia de contactos. Pruebas eléctricas a transformadores de potencial. Revisión funcional al interruptor de potencia del enlace de barras.
- 65: Text4: Mantenimiento general a seccionadoras de barra principal, lavado, lubricación, ajustes y pruebas de resisitencia de contactos. Pruebas eléctricas a transformadores de potencial.
- 66: Text4: Sustitución de piezas dañadas, herrajes y aislamiento, se realizará la reconstrucción de seccionadoras 289L-3, 289L-5 y 189M-3.
- 67: Text4: Mantenimiento general a seccionadoras de barra principal, lavado, lubricación, ajustes y pruebas de resisitencia de contactos. Pruebas eléctricas a transformadores de potencial.
- 68: Text4: Mantenimiento general a seccionadoras de barra principal, lavado, lubricación, ajustes y pruebas de resisitencia de contactos. Pruebas eléctricas a transformadores de potencial.
- 69: Text4: Mantenimiento, ajuste, lubricación y pruebas a seccionadoras de línea, puesta a tierra y derivación. Mantenimiento general y pruebas eléctricas a transformadores de instrumentos, y pararrayos.Revisión funcional del interruptor de potencia. Cambio de aisl
- 70: Text4: Prueba relé diferencial de barras 87B. Prueba de disparos locales y transferidos. Revisión funcional del interruptor de potencia del enlace de barras.

| ID | Task | Type | Duration | Start | Finish | Text3 | SOLMANT |
| --- | --- | --- | --- | --- | --- | --- | --- |
| 71 | Subestación San Miguel Autotransformador #1 | manual | 4.33d | 2021-10-26 07:00 | 2021-10-30 15:00 | RCN | no RTR |
| 72 | Subestación San Miguel Autotransformador #2 | manual | 4.33d | 2021-11-01 07:00 | 2021-11-05 15:00 | RCN | no RTR |
| 73 | Subestación San Miguel Autotransformador #3 | manual | 4.33d | 2021-11-08 07:00 | 2021-11-12 15:00 | RCN | no RTR |
| 74 | Subestación San Miguel Barra A 138kV | manual | 0.42d | 2021-11-14 07:00 | 2021-11-14 17:00 | RCN | no RTR |
| 75 | LT230kV Río Macho San Isidro | manual | 0.42d | 2021-12-09 07:00 | 2021-12-09 17:00 | RHT | 50 |
| 76 | Subestación Cariblanco Enlace de barras 230kV | manual | 0.42d | 2021-12-08 07:00 | 2021-12-08 17:00 | RCN | 49 |

Notes:
- 71: Text4: Revisión funcional y pruebas eléctricas. Revisión y pruebas funcionales a protecciones.
- 72: Text4: Revisión funcional del Autotransformador. Pruebas electricas por LIMAT. Revisión y pruebas funcionales a Protecciones
- 73: Text4: Revisión funcional del Autotransformador. Pruebas electricas por LIMAT. Revisión y pruebas funcionales a Protecciones
- 74: Text4: Prueba relé diferencial de barras 87B. Prueba de disparos locales y transferidos. Cambio de aisladores epóxicos.
- 75: Text4: Instalación poste polimérico
- 76: Text4: Revisión funcional del interruptor de potencia
